# MPP template for Microsoft Project

Schedule from MS Project, 2015-09-01 to 2016-06-13.
Successful campaigns tend to be carefully researched, well thought out, and focused on details and execution. Planning a marketing campaign begins with understanding your position in the marketplace and ends with collecting data and analyzing campaign effectiveness. This template outlines the various considerations you might need to plan a marketing campaign in your organization.

## Calendars

- Standard: Mon-Fri 08:00-12:00, 13:00-17:00; Sat-Sun off.

## Resources

| Resource |
| --- |
| Logistics Lead |
| Marketing Lead |
| Sponsor |
| Sales |
| Creative |
| Content Consultant |
| Marketing |
| Marketing Research |
| Corporate Sponsor |
| Subject Matter Expert |
| Inside Sales |
| Marketing Staff |
| Product Marketing |
| Regional General Manager |
| Country Manager |
| Strategic Alliance Lead |
| Marketing Rep |
| Marketing Research |
| Internal PR |
| PR Company |
| Vendor |

## Schedule

| ID | WBS | Task | Type | Duration | Start | Finish | Predecessors | Total slack | Free slack | Resources | Work |
| --- | --- | --- | --- | --- | --- | --- | --- | --- | --- | --- | --- |
| 1 | 1 | **Review Business Strategy Landscape** |  | 27d | 2015-09-01 | 2015-10-07 |  | 0d |  |  | 256h |
| 2 | 1.1 | Identify service/product gaps and opportunities |  | 5d | 2015-09-01 | 2015-09-07 |  | 0d |  | Marketing Lead | 40h |
| 3 | 1.2 | Complete SWOT analysis |  | 5d | 2015-09-08 | 2015-09-14 | 2 | 0d |  | Marketing Lead | 40h |
| 4 | 1.3 | Review business model |  | 1d | 2015-09-15 | 2015-09-15 | 3 | 0d |  | Marketing Lead | 8h |
| 5 | 1.4 | Review organizational marketing strategy |  | 3d | 2015-09-16 | 2015-09-18 | 4 | 0d |  | Marketing Lead | 24h |
| 6 | 1.5 | Review local marketing strategy |  | 1d | 2015-09-21 | 2015-09-21 | 5 | 0d |  | Marketing Lead | 8h |
| 7 | 1.6 | Review global marketing strategy |  | 1d | 2015-09-22 | 2015-09-22 | 6 | 0d |  | Marketing Rep | 8h |
| 8 | 1.7 | Review marketing plan for campaign budget |  | 1d | 2015-09-23 | 2015-09-23 | 7 | 0d |  | Marketing Rep | 8h |
| 9 | 1.8 | Establish go-to-markets for organization |  | 1d | 2015-09-24 | 2015-09-24 | 8 | 0d |  | Marketing Lead | 8h |
| 10 | 1.9 | Evaluate alignment to corporate strategy goals |  | 2d | 2015-09-25 | 2015-09-28 | 9 | 0d |  | Marketing Lead; Sponsor | 32h |
| 11 | 1.10 | Evaluate competitive advantages |  | 3d | 2015-09-29 | 2015-10-01 | 10 | 0d |  | Marketing Lead; Marketing Research | 48h |
| 12 | 1.11 | Review product and service margins |  | 3d | 2015-10-02 | 2015-10-06 | 11 | 0d |  | Marketing Lead | 24h |
| 13 | 1.12 | Review previous campaign performance |  | 1d | 2015-10-07 | 2015-10-07 | 12 | 0d |  | Marketing Lead | 8h |
| 14 | 1.13 | Business Strategy Landscape Review Complete | milestone | 0d | 2015-10-07 | 2015-10-07 | 13 | 0d |  |  |  |
| 15 | 2 | **Develop Campaign Concepts** |  | 49d | 2015-10-08 | 2015-12-15 |  | 0d |  |  | 504h |
| 16 | 2.1 | Create process for qualifying ideas |  | 5d | 2015-10-08 | 2015-10-14 | 14 | 0d |  | Marketing Staff | 40h |
| 17 | 2.2 | Establish process for idea sharing |  | 5d | 2015-10-15 | 2015-10-21 | 16 | 0d |  | Marketing Staff | 40h |
| 18 | 2.3 | Gather ideas |  | 1d | 2015-10-22 | 2015-10-22 | 17 | 0d |  |  |  |
| 19 | 2.4 | Final shaping and development of ideas |  | 5d | 2015-10-23 | 2015-10-29 | 18 | 0d |  | Marketing Lead | 40h |
| 20 | 2.5 | Research market environment |  | 5d | 2015-10-30 | 2015-11-05 | 19 | 0d |  | Marketing Research | 40h |
| 21 | 2.6 | Develop preliminary campaign concepts |  | 5d | 2015-11-06 | 2015-11-12 | 20 | 0d |  | Marketing Lead | 40h |
| 22 | 2.7 | Identify campaign targets |  | 2d | 2015-11-13 | 2015-11-16 | 21 | 0d |  | Marketing Lead | 16h |
| 23 | 2.8 | Develop campaign success metrics |  | 2d | 2015-11-17 | 2015-11-18 | 22 | 0d |  | Marketing Rep | 16h |
| 24 | 2.9 | Develop campaign tracking and analysis process |  | 3d | 2015-11-19 | 2015-11-23 | 23 | 0d |  | Marketing Staff | 24h |
| 25 | 2.10 | Validate concepts through test groups and market research |  | 5d | 2015-11-24 | 2015-11-30 | 24 | 0d |  | Marketing Rep | 40h |
| 26 | 2.11 | Establish campaign focus list |  | 1d | 2015-12-01 | 2015-12-01 | 25 | 0d |  | Marketing Rep | 8h |
| 27 | 2.12 | Establish campaign categories |  | 1d | 2015-12-02 | 2015-12-02 | 26 | 5d | 0d | Marketing Rep | 8h |
| 28 | 2.13 | Develop public relations strategy |  | 3d | 2015-12-03 | 2015-12-07 | 27 | 5d | 0d | Internal PR | 24h |
| 29 | 2.14 | Establish preliminary ideal campaign timing for promotion |  | 1d | 2015-12-08 | 2015-12-08 | 28 | 5d |  | Marketing Rep | 8h |
| 30 | 2.15 | Determine organization regional campaigns |  | 5d | 2015-12-02 | 2015-12-08 | 26 | 0d |  | Marketing Lead | 40h |
| 31 | 2.16 | Determine organization global campaigns |  | 5d | 2015-12-02 | 2015-12-08 | 26 | 0d |  | Marketing Lead | 40h |
| 32 | 2.17 | Determine organization country campaigns |  | 5d | 2015-12-02 | 2015-12-08 | 26 | 0d |  | Marketing Lead | 40h |
| 33 | 2.18 | Identify localization requirements |  | 5d | 2015-12-09 | 2015-12-15 | 30, 31, 32 | 0d |  | Marketing Staff | 40h |
| 34 | 2.19 | Campaign Concepts Complete | milestone | 0d | 2015-12-15 | 2015-12-15 | 33, 29 | 0d |  |  |  |

Notes:
- 3: SWOT - strengths, weaknesses, opportunities, threats

| ID | WBS | Task | Type | Duration | Start | Finish | Predecessors | Total slack | Free slack | Resources | Work |
| --- | --- | --- | --- | --- | --- | --- | --- | --- | --- | --- | --- |
| 35 | 3 | **Create Localization Strategy** |  | 18d | 2015-12-16 | 2016-01-08 |  | 0d |  |  | 224h |
| 36 | 3.1 | Review corporate sales objectives |  | 1d | 2015-12-16 | 2015-12-16 | 34 | 0d |  | Marketing Staff | 8h |
| 37 | 3.2 | Review regional business models |  | 1d | 2015-12-16 | 2015-12-16 | 34 | 0d |  | Marketing Rep | 8h |
| 38 | 3.3 | Review global/country business models |  | 1d | 2015-12-16 | 2015-12-16 | 34 | 0d |  | Marketing Rep | 8h |
| 39 | 3.4 | Review marketing objectives |  | 1d | 2015-12-16 | 2015-12-16 | 34 | 0d |  | Marketing Rep | 8h |
| 40 | 3.5 | Review marketing plan |  | 1d | 2015-12-16 | 2015-12-16 | 34 | 0d |  | Marketing Rep | 8h |
| 41 | 3.6 | Establish campaign opportunities |  | 3d | 2015-12-17 | 2015-12-21 | 36, 37, 38, 39, 40 | 0d |  | Marketing Rep | 24h |
| 42 | 3.7 | Review services and product mix and forecast |  | 3d | 2015-12-22 | 2015-12-24 | 41 | 0d |  | Marketing Rep | 24h |
| 43 | 3.8 | Review product release cycles |  | 3d | 2015-12-25 | 2015-12-29 | 42 | 6d |  | Marketing Rep | 24h |
| 44 | 3.9 | Determine campaign mix for each region |  | 3d | 2015-12-25 | 2015-12-29 | 42 | 0d |  | Marketing Lead | 24h |
| 45 | 3.10 | Determine campaign success measures for each region |  | 3d | 2015-12-30 | 2016-01-01 | 44 | 0d |  | Marketing Lead; Regional General Manager | 48h |
| 46 | 3.11 | Determine tracking mechanism |  | 3d | 2016-01-04 | 2016-01-06 | 45 | 0d |  | Marketing Staff | 24h |
| 47 | 3.12 | Create localization strategy |  | 2d | 2016-01-07 | 2016-01-08 | 46, 44, 43 | 0d |  | Marketing Staff | 16h |
| 48 | 3.13 | Localization Strategy Complete | milestone | 0d | 2016-01-08 | 2016-01-08 | 47 | 0d |  |  |  |
| 49 | 4 | **Communicate and Train Internal Organization** |  | 24d | 2016-01-11 | 2016-02-11 |  | 0d |  |  | 240h |
| 50 | 4.1 | Establish corporate internal communications process |  | 3d | 2016-01-11 | 2016-01-13 | 48 | 0d |  | Marketing Staff | 24h |
| 51 | 4.2 | Determine regional and country division communications process |  | 5d | 2016-01-14 | 2016-01-20 | 50 | 0d |  | Marketing Staff | 40h |
| 52 | 4.3 | Plan communications methods, logistics, and timing |  | 4d | 2016-01-21 | 2016-01-26 | 51 | 0d |  | Marketing Staff; Logistics Lead | 64h |
| 53 | 4.4 | Regional and country communications to sales, marketing, and management |  | 5d | 2016-01-27 | 2016-02-02 | 52 | 0d |  | Marketing Rep | 40h |
| 54 | 4.5 | Determine internal systems to respond to campaign |  | 5d | 2016-02-03 | 2016-02-09 | 53 | 0d |  | Marketing Staff | 40h |
| 55 | 4.6 | Create communications plan |  | 2d | 2016-02-10 | 2016-02-11 | 54 | 0d |  |  |  |
| 56 | 4.7 | Identify internal training requirements |  | 1d | 2016-01-11 | 2016-01-11 | 48 | 20d | 0d | Marketing Staff | 8h |
| 57 | 4.8 | Develop internal training |  | 3d | 2016-01-12 | 2016-01-14 | 56 | 20d |  | Marketing Staff | 24h |
| 58 | 4.9 | Organization Internal Communications and Training Complete | milestone | 0d | 2016-02-11 | 2016-02-11 | 55, 57 | 0d |  |  |  |

| ID | WBS | Task | Type | Duration | Start | Finish | Predecessors | Total slack | Free slack | Resources | Work |
| --- | --- | --- | --- | --- | --- | --- | --- | --- | --- | --- | --- |
| 59 | 5 | **Customer Relationship Management** |  | 16d | 2016-01-11 | 2016-02-01 |  | 8d |  |  | 152h |
| 60 | 5.1 | Review customer data and feedback |  | 3d | 2016-01-11 | 2016-01-13 | 48 | 8d | 0d | Marketing Staff | 24h |
| 61 | 5.2 | Review company segments and channels |  | 3d | 2016-01-11 | 2016-01-13 | 48 | 8d | 0d | Marketing Staff | 24h |
| 62 | 5.3 | Identify targets for each campaign |  | 3d | 2016-01-14 | 2016-01-18 | 60, 61 | 8d | 0d | Marketing Research | 24h |
| 63 | 5.4 | Segment data for each campaign |  | 5d | 2016-01-19 | 2016-01-25 | 62 | 8d | 0d | Marketing Staff | 40h |
| 64 | 5.5 | Prepare/procure lists for each campaign |  | 5d | 2016-01-26 | 2016-02-01 | 63 | 8d | 0d | Marketing Staff | 40h |
| 65 | 5.6 | Customer Relationship Management Complete | milestone | 0d | 2016-02-01 | 2016-02-01 | 64 | 8d |  |  |  |
| 66 | 6 | **Analyze Regional/Global/Country Business Models** |  | 9d | 2016-01-11 | 2016-01-21 |  | 15d |  |  | 88h |
| 67 | 6.1 | Establish target regions |  | 1d | 2016-01-11 | 2016-01-11 | 48 | 15d | 0d | Marketing Staff | 8h |
| 68 | 6.2 | Determine local gaps |  | 2d | 2016-01-12 | 2016-01-13 | 67 | 15d | 0d | Marketing Staff | 16h |
| 69 | 6.3 | Review local competition |  | 3d | 2016-01-14 | 2016-01-18 | 68 | 15d | 0d | Marketing Research | 24h |
| 70 | 6.4 | Develop competitive advantage |  | 2d | 2016-01-19 | 2016-01-20 | 69 | 15d | 0d | Marketing Research; Marketing Lead | 32h |
| 71 | 6.5 | Identify go-to partners |  | 1d | 2016-01-21 | 2016-01-21 | 70 | 15d | 0d | Strategic Alliance Lead | 8h |
| 72 | 6.6 | Regional/Global/Country Business Models Complete | milestone | 0d | 2016-01-21 | 2016-01-21 | 71 | 15d |  |  |  |
| 73 | 7 | **Develop Campaign** |  | 14d | 2016-02-12 | 2016-03-02 |  | 0d |  |  | 104h |
| 74 | 7.1 | Review campaign concepts |  | 2d | 2016-02-12 | 2016-02-15 | 58, 65, 72 | 0d |  | Marketing Lead | 16h |
| 75 | 7.2 | Create campaign list |  | 1d | 2016-02-16 | 2016-02-16 | 74 | 0d |  | Marketing Rep | 8h |
| 76 | 7.3 | Identify campaign leads |  | 1d | 2016-02-17 | 2016-02-17 | 75 | 0d |  | Marketing Rep | 8h |
| 77 | 7.4 | Develop Individual campaigns |  | 1d | 2016-02-18 | 2016-02-18 | 76 | 0d |  |  |  |
| 78 | 7.5 | Develop campaign schedules |  | 2d | 2016-02-19 | 2016-02-22 | 77 | 0d |  | Marketing Rep | 16h |
| 79 | 7.6 | Determine calls to action |  | 2d | 2016-02-23 | 2016-02-24 | 78 | 0d |  | Marketing Lead | 16h |
| 80 | 7.7 | Determine advertising/promotion methods and mix |  | 5d | 2016-02-25 | 2016-03-02 | 79 | 0d |  | Marketing Lead | 40h |
| 81 | 7.8 | Campaign Development Complete | milestone | 0d | 2016-03-02 | 2016-03-02 | 80 | 0d |  |  |  |
| 82 | 8 | **Develop Campaign Creative and Testing** |  | 30d | 2016-03-03 | 2016-04-13 |  | 0d |  |  | 312h |
| 83 | 8.1 | Select vendor for creative |  | 1d | 2016-03-03 | 2016-03-03 | 81 | 0d |  | Marketing Rep; Marketing Lead | 16h |
| 84 | 8.2 | Determine campaign voice/messaging style |  | 3d | 2016-03-04 | 2016-03-08 | 83 | 0d |  | Creative; Marketing Lead | 48h |
| 85 | 8.3 | Develop concepts and comps |  | 5d | 2016-03-09 | 2016-03-15 | 84 | 0d |  | Creative | 40h |
| 86 | 8.4 | Select creative for campaign |  | 5d | 2016-03-16 | 2016-03-22 | 85 | 0d |  | Marketing Lead; Corporate Sponsor | 80h |
| 87 | 8.5 | Prepare pretest materials |  | 5d | 2016-03-23 | 2016-03-29 | 86 | 0d |  | Marketing Rep | 40h |
| 88 | 8.6 | Pretest campaign |  | 5d | 2016-03-30 | 2016-04-05 | 87 | 0d |  | Marketing Rep | 40h |
| 89 | 8.7 | Determine if pretest creative achieves objectives |  | 1d | 2016-04-06 | 2016-04-06 | 88 | 0d |  | Marketing Rep | 8h |
| 90 | 8.8 | Improve creative based on pretest results |  | 5d | 2016-04-07 | 2016-04-13 | 89 | 0d |  | Creative | 40h |
| 91 | 8.9 | Campaign Creative and Testing Complete | milestone | 0d | 2016-04-13 | 2016-04-13 | 90 | 0d |  |  |  |

| ID | WBS | Task | Type | Duration | Start | Finish | Predecessors | Total slack | Free slack | Resources | Work |
| --- | --- | --- | --- | --- | --- | --- | --- | --- | --- | --- | --- |
| 92 | 9 | **Develop Strategy for External Promotions** |  | 9d | 2016-04-14 | 2016-04-26 |  | 0d |  |  | 368h |
| 93 | 9.1 | Develop promotion strategy |  | 2d | 2016-04-14 | 2016-04-15 | 91 | 0d |  | Marketing Lead; Internal PR | 32h |
| 94 | 9.2 | Develop press releases |  | 4d | 2016-04-18 | 2016-04-21 | 93 | 0d |  | Internal PR; PR Company | 64h |
| 95 | 9.3 | Develop announcements |  | 4d | 2016-04-18 | 2016-04-21 | 93 | 0d |  | Internal PR; PR Company | 64h |
| 96 | 9.4 | Provide pre-release information to analysts |  | 3d | 2016-04-22 | 2016-04-26 | 94, 95 | 0d |  | Internal PR; PR Company | 48h |
| 97 | 9.5 | Generate 'buzz' |  | 5d | 2016-04-18 | 2016-04-22 | 93 | 2d |  | Internal PR; PR Company | 80h |
| 98 | 9.6 | Execute publicity strategy |  | 5d | 2016-04-14 | 2016-04-20 | 91 | 4d |  | Internal PR; PR Company | 80h |
| 99 | 9.7 | Promotion - External Complete | milestone | 0d | 2016-04-26 | 2016-04-26 | 98, 96, 97 | 0d |  |  |  |
| 100 | 10 | **Production** |  | 14d | 2016-04-27 | 2016-05-16 |  | 0d |  |  | 112h |
| 101 | 10.1 | Submit campaign material for broadcast publications |  | 3d | 2016-04-27 | 2016-04-29 | 99 | 0d |  | Marketing Rep | 24h |
| 102 | 10.2 | Select vendor for appropriate production methods |  | 1d | 2016-05-02 | 2016-05-02 | 101 | 20d | 0d | Marketing Staff | 8h |
| 103 | 10.3 | Production of materials |  | 5d | 2016-05-03 | 2016-05-09 | 102 | 20d | 0d | Vendor | 40h |
| 104 | 10.4 | Dissemination of materials |  | 5d | 2016-05-10 | 2016-05-16 | 103 | 20d | 0d | Vendor | 40h |
| 105 | 10.5 | Production Complete | milestone | 0d | 2016-05-16 | 2016-05-16 | 104 | 20d |  |  |  |
| 106 | 11 | **Campaign Release** |  | 13d | 2016-05-02 | 2016-05-18 |  | 0d |  |  | 144h |
| 107 | 11.1 | Develop campaign release schedules |  | 2d | 2016-05-02 | 2016-05-03 | 101 | 0d |  | Marketing Rep | 16h |
| 108 | 11.2 | Determine release teams |  | 1d | 2016-05-04 | 2016-05-04 | 107 | 0d |  | Marketing Lead | 8h |
| 109 | 11.3 | Perform Inside sales calls |  | 5d | 2016-05-05 | 2016-05-11 | 108 | 0d |  | Marketing Lead; Inside Sales | 80h |
| 110 | 11.4 | Execute campaign |  | 5d | 2016-05-12 | 2016-05-18 | 109 | 0d |  | Marketing Lead | 40h |
| 111 | 11.5 | Campaign Release Complete | milestone | 0d | 2016-05-18 | 2016-05-18 | 110 | 0d |  |  |  |
| 112 | 12 | **Campaign Effectiveness** |  | 18d | 2016-05-19 | 2016-06-13 |  | 0d |  |  | 192h |
| 113 | 12.1 | Evaluate campaign effectiveness |  | 3d | 2016-05-19 | 2016-05-23 | 111 | 3d |  | Marketing Lead | 24h |
| 114 | 12.2 | Review regional sales |  | 1d | 2016-05-19 | 2016-05-19 | 111 | 0d |  | Marketing Lead; Sales | 16h |
| 115 | 12.3 | Review global sales |  | 1d | 2016-05-20 | 2016-05-20 | 114 | 0d |  | Marketing Lead; Sales | 16h |
| 116 | 12.4 | Review customer data and feedback |  | 1d | 2016-05-23 | 2016-05-23 | 115 | 0d |  | Marketing Rep; Marketing Staff | 16h |
| 117 | 12.5 | Perform market analysis |  | 3d | 2016-05-24 | 2016-05-26 | 116 | 0d |  | Marketing Research | 24h |
| 118 | 12.6 | Review success measures |  | 3d | 2016-05-27 | 2016-05-31 | 113, 114, 115, 116, 117 | 0d |  | Marketing Lead | 24h |
| 119 | 12.7 | Measure campaign effectiveness |  | 3d | 2016-06-01 | 2016-06-03 | 118 | 0d |  | Marketing Lead | 24h |
| 120 | 12.8 | Identify any gaps |  | 1d | 2016-06-06 | 2016-06-06 | 119 | 0d |  | Marketing Lead | 8h |
| 121 | 12.9 | Develop future campaign ideas |  | 5d | 2016-06-07 | 2016-06-13 | 120 | 0d |  | Marketing Lead | 40h |
| 122 | 12.10 | Campaign Effectiveness | milestone | 0d | 2016-06-13 | 2016-06-13 | 121 | 0d |  |  |  |
| 123 | 13 | Marketing Campaign Planning Complete | milestone | 0d | 2016-06-13 | 2016-06-13 | 122 | 0d |  |  |  |

Notes:
- 92: You may have a more detailed PR schedule to manage the work for this section of the campaign execution.
